# My Shed2a

Schedule from MS Project, 2005-07-07 to 2005-07-29, costs in $.
.

## Calendars

- Standard: Mon-Fri 08:00-12:00, 13:00-17:00; Sat-Sun off.

## Resources

| Resource | Rate |
| --- | --- |
| Andy Handy | 25 |
| Betty Doe | 10 |
| Frank Doe | 10 |
| John Doe |  |
| Shed Kit | 1250 |

## Schedule

| ID | WBS | Task | Type | Duration | Start | Finish | Predecessors | Baseline start | Baseline finish | Baseline duration | Total slack | Free slack | Constraint | Resources | Work | Cost | Baseline cost |
| --- | --- | --- | --- | --- | --- | --- | --- | --- | --- | --- | --- | --- | --- | --- | --- | --- | --- |
| 1 | 1 | Order kit & schedule delivery |  | 1d | 2005-07-07 | 2005-07-07 |  | 2005-07-07 | 2005-07-07 | 1d | 4d | 0d |  | John Doe [25%] | 2h |  |  |
| 2 | 2 | **Preparation** |  | 7d | 2005-07-07 | 2005-07-15 | 1SS | 2005-07-07 | 2005-07-15 | 7d | 0d |  |  |  | 46h | 365 | 365 |
| 3 | 2.1 | Site preparation |  | 2d | 2005-07-07 | 2005-07-08 |  | 2005-07-07 | 2005-07-08 | 2d | 4d |  |  | Betty Doe [75%]; Frank Doe [75%]; John Doe [75%] | 36h | 240 | 240 |
| 4 | 2.2 | Pour the foundation |  | 1d | 2005-07-15 | 2005-07-15 | 3 | 2005-07-15 | 2005-07-15 | 1d | 0d |  | start no earlier than 2005-07-15 | John Doe [62.5%]; Andy Handy [62.5%] | 10h | 125 | 125 |
| 5 | 3 | Receive the delivery |  | 1d | 2005-07-21 | 2005-07-21 | 2FS+3d | 2005-07-21 | 2005-07-21 | 1d | 0d |  |  | John Doe [25%] | 2h |  |  |
| 6 | 4 | Delivery milestone | milestone | 0d | 2005-07-21 | 2005-07-21 | 5 | 2005-07-21 | 2005-07-21 | 0d | 6d |  |  |  |  |  |  |
| 7 | 5 | **Assembly** |  | 6d | 2005-07-21 | 2005-07-28 | 5SS | 2005-07-21 | 2005-07-28 | 6d | 0d |  |  |  | 28h | 330 | 330 |
| 8 | 5.1 | Assemble kit |  | 2d | 2005-07-21 | 2005-07-22 |  | 2005-07-21 | 2005-07-22 | 2d | 0d |  |  | John Doe [62.5%]; Andy Handy [62.5%] | 20h | 250 | 250 |
| 9 | 5.2 | Stain the shed |  | 1d | 2005-07-28 | 2005-07-28 | 8FS+3d | 2005-07-28 | 2005-07-28 | 1d | 0d |  |  | Frank Doe [25%]; Betty Doe [25%] | 4h | 40 | 40 |
| 10 | 5.3 | Plant landscaping |  | 1d | 2005-07-28 | 2005-07-28 | 9SS | 2005-07-28 | 2005-07-28 | 1d | 0d |  |  | Betty Doe [50%] | 4h | 40 | 40 |
| 11 | 6 | Fill the shed |  | 1d | 2005-07-29 | 2005-07-29 | 7 | 2005-07-29 | 2005-07-29 | 1d | 0d |  |  | John Doe [62.5%]; Frank Doe [62.5%] | 10h | 50 | 50 |
