# My Shed3a

Schedule from MS Project, 2005-07-07 to 2005-08-05, costs in $, A marks actual dates.
.

## Calendars

- Standard: Mon-Fri 08:00-12:00, 13:00-17:00; Sat-Sun off.

## Resources

| Resource | Rate |
| --- | --- |
| Andy Handy | 25 |
| Betty Doe | 10 |
| Frank Doe | 10 |
| John Doe |  |
| Shed Kit | 1250 |

## Schedule

| ID | WBS | Task | Type | Duration | Start | Finish | Predecessors | Complete | Baseline start | Baseline finish | Baseline duration | Total slack | Constraint | Resources | Work | Actual work | Cost | Baseline cost | Actual cost |
| --- | --- | --- | --- | --- | --- | --- | --- | --- | --- | --- | --- | --- | --- | --- | --- | --- | --- | --- | --- |
| 1 | 1 | Order kit & schedule delivery |  | 1d | 2005-07-07 A | 2005-07-07 A |  | 100% | 2005-07-07 | 2005-07-07 | 1d |  |  | John Doe [25%] | 2h | 2h |  |  |  |
| 2 | 2 | **Preparation** |  | 7d | 2005-07-07 A | 2005-07-15 A | 1SS | 100% | 2005-07-07 | 2005-07-15 | 7d |  |  |  | 34h | 34h | 285 | 365 | 285 |
| 3 | 2.1 | Site preparation |  | 2d | 2005-07-07 A | 2005-07-08 A |  | 100% | 2005-07-07 | 2005-07-08 | 2d |  |  | Betty Doe [50%]; Frank Doe [50%]; John Doe [50%] | 24h | 24h | 160 | 240 | 160 |
| 4 | 2.2 | Pour the foundation |  | 1d | 2005-07-15 A | 2005-07-15 A | 3 | 100% | 2005-07-15 | 2005-07-15 | 1d |  | start no earlier than 2005-07-15 | John Doe [62.5%]; Andy Handy [62.5%] | 10h | 10h | 125 | 125 | 125 |
| 5 | 3 | Receive the delivery |  | 1d | 2005-07-21 A | 2005-07-21 A | 2FS+3d | 100% | 2005-07-21 | 2005-07-21 | 1d |  |  | John Doe [12.5%] | 1h | 1h |  |  |  |
| 6 | 4 | Delivery milestone | milestone | 0d | 2005-07-21 A | 2005-07-21 A | 5 | 100% | 2005-07-21 | 2005-07-21 | 0d |  |  |  |  |  |  |  |  |
| 7 | 5 | **Assembly** |  | 10d | 2005-07-22 | 2005-08-04 | 5SS |  | 2005-07-21 | 2005-07-28 | 6d | 0d |  |  | 28h |  | 330 | 330 |  |
| 8 | 5.1 | Assemble kit |  | 5d | 2005-07-22 | 2005-07-28 |  |  | 2005-07-21 | 2005-07-22 | 2d | 0d | start no earlier than 2005-07-22 | John Doe [25%]; Andy Handy [25%] | 20h |  | 250 | 250 |  |
| 9 | 5.2 | Stain the shed |  | 1d | 2005-08-04 | 2005-08-04 | 8FS+4d |  | 2005-07-28 | 2005-07-28 | 1d | 0d |  | Frank Doe [25%]; Betty Doe [25%] | 4h |  | 40 | 40 |  |
| 10 | 5.3 | Plant landscaping |  | 1d | 2005-08-04 | 2005-08-04 | 9SS |  | 2005-07-28 | 2005-07-28 | 1d | 0d |  | Betty Doe [50%] | 4h |  | 40 | 40 |  |
| 11 | 6 | Fill the shed |  | 1d | 2005-08-05 | 2005-08-05 | 7 |  | 2005-07-29 | 2005-07-29 | 1d | 0d |  | John Doe [62.5%]; Frank Doe [62.5%] | 10h |  | 50 | 50 |  |
